# GD-04 - met gevel-dak problemen

Schedule from MS Project, 2003-01-12 to 2003-02-20, status date 2003-01-08.
BAM Nelissen Van Egteren

## Calendars

- ALLEEN WERKDAGEN: Mon-Fri 08:30-12:30, 13:00-17:00; Sat-Sun off. Exceptions (off unless hours are given): 2003-01-11 to 2003-01-12 08:30-12:30, 13:00-17:00, 2003-01-18 to 2003-01-19 08:30-12:30, 13:00-17:00, 2003-01-25 to 2003-01-26 08:30-12:30, 13:00-17:00, 2003-02-01 to 2003-02-02 08:30-12:30, 13:00-17:00, 2003-02-08 to 2003-02-09 08:30-12:30, 13:00-17:00, 2003-02-15 to 2003-02-16 08:30-12:30, 13:00-17:00.

## Schedule

| ID | WBS | Task | Type | Duration | Start | Finish | Predecessors | Total slack |
| --- | --- | --- | --- | --- | --- | --- | --- | --- |
| 1 | 1 | **GEVEL-DAK FASE** |  | 40d | 2003-01-12 | 2003-02-20 |  | 0d |
| 2 | 1.1 | beg.grond kozijnen+profielen |  | 2d | 2003-01-12 | 2003-01-13 |  | 0d |
| 3 | 1.2 | beg.grond metselen 1e slag |  | 5d | 2003-01-13 | 2003-01-17 | 2SS+1d | 0d |
| 4 | 1.3 | steiger opbouwen vanaf maaiv. |  | 2d | 2003-01-17 | 2003-01-18 | 3SS+4d | 0d |
| 5 | 1.4 | beg.grond metselen 2e slag |  | 5d | 2003-01-18 | 2003-01-22 | 4SS+1d | 0d |
| 6 | 1.5 | steiger opbouwen tot verd |  | 2d | 2003-01-22 | 2003-01-23 | 5SS+4d | 0d |
| 7 | 1.6 | prefab balkons op metselwerk |  | 2d | 2003-01-24 | 2003-01-25 | 6SS+2d | 0d |
| 8 | 1.7 | verd. kozijnen+profielen |  | 2d | 2003-01-25 | 2003-01-26 | 7SS+1d | 0d |
| 9 | 1.8 | verd. metselen 3e slag |  | 5d | 2003-01-26 | 2003-01-30 | 8SS+1d | 0d |
| 10 | 1.9 | steiger opbouwen |  | 2d | 2003-01-30 | 2003-01-31 | 9SS+4d | 0d |
| 11 | 1.10 | verd. metselen 4e slag |  | 5d | 2003-01-31 | 2003-02-04 | 10SS+1d | 0d |
| 12 | 1.11 | dak muurplaat+gootbeugels |  | 3d | 2003-02-05 | 2003-02-07 | 11SS+5d | 0d |
| 13 | 1.12 | dak gordingen+ravelingen |  | 3d | 2003-02-07 | 2003-02-09 | 12SS+2d | 0d |
| 14 | 1.13 | dak prefab dakelementen |  | 3d | 2003-02-09 | 2003-02-11 | 13SS+2d | 0d |
| 15 | 1.14 | panlatten+dakrandvoorz. |  | 3d | 2003-02-11 | 2003-02-13 | 14SS+2d | 0d |
| 16 | 1.15 | complexe bakgoot maken |  | 3d | 2003-02-13 | 2003-02-15 | 15SS+2d | 0d |
| 17 | 1.16 | dakpannen leggen |  | 3d | 2003-02-16 | 2003-02-18 | 16SS+3d | 0d |
| 18 | 1.17 | dakramen+dakdoorvoeren |  | 3d | 2003-02-18 | 2003-02-20 | 17SS+2d | 0d |
| 19 | 1.18 | kozijnen waterdicht maken |  | 3d | 2003-02-18 | 2003-02-20 | 18SS | 0d |
| 20 | 1.19 | start afbouw fase | milestone | 0d | 2003-02-20 | 2003-02-20 | 19SS+3d | 0d |
